# ProjectPlan2011

Schedule from MS Project, 2011-01-03 to 2011-10-28, costs in $.

## Calendars

- Standard: Mon-Fri 08:00-12:00, 13:00-17:00; Sat-Sun off. Exceptions (off unless hours are given): 2011-09-17 08:00-12:00, 13:00-17:00.

## Resources

| Resource |
| --- |
| Gene Massion |
| Paul Coenen |
| Mike Parker |
| Brent Roman |
| Electrical Techs |
| Machine Shop |
| Scott Jensen |
| Jim Scholfield |
| John Ryan |
| Dale Graves |

## Schedule

| ID | WBS | Task | Duration | Start | Finish | Predecessors | Total slack | Free slack | Resources | Work | Cost |
| --- | --- | --- | --- | --- | --- | --- | --- | --- | --- | --- | --- |
| 1 | 1 | **Design** | 50d? | 2011-01-03 | 2011-03-11 |  | -41d | 0d |  | 605.33h | 10,000 |
| 2 | 1.1 | **Network/telemetry architecture** | 50d? | 2011-01-03 | 2011-03-11 |  | -41d | 0d | Brent Roman [33.3%] | 533.33h |  |
| 3 | 1.1.1 | Design review | 10d? | 2011-01-03 | 2011-01-14 |  | -41d | 0d | Brent Roman | 80h |  |
| 4 | 1.1.2 | 1st demo | 30d? | 2011-01-17 | 2011-02-25 | 3 | -41d | 0d | Brent Roman | 240h |  |
| 5 | 1.1.3 | Final changes | 10d? | 2011-02-28 | 2011-03-11 | 4 | -41d | 0d | Brent Roman | 80h |  |
| 6 | 1.2 | Buoy analysis | 20d | 2011-01-03 | 2011-01-28 |  | -11d | 0d | Gene Massion [25%] | 40h | 10,000 |
| 7 | 1.3 | PAR sensor selection | 2d | 2011-01-03 | 2011-01-04 |  | 5d | 0d | John Ryan | 16h |  |
| 8 | 1.4 | ADCP review | 2d | 2011-01-05 | 2011-01-06 | 7 | 5d |  | John Ryan | 16h |  |
| 9 | 2 | **Buy** | 30d? | 2011-01-03 | 2011-02-11 |  | 73d | 0d |  | 16h | 30,000 |
| 10 | 2.1 | Network/telemetry equipment | 0.2d | 2011-01-03 | 2011-01-03 |  | 102.8d | 0d | Brent Roman | 1.6h |  |
| 11 | 2.2 | New buoy (as req'd) | 1d | 2011-01-03 | 2011-01-03 |  | 73d | 0d | Gene Massion | 8h | 9,000 |
| 12 | 2.3 | New buoy delivery | 1d? | 2011-02-11 | 2011-02-11 | 11FS+28d | 73d | 0d |  |  |  |
| 13 | 2.4 | PAR sensor | 0.2d | 2011-01-03 | 2011-01-03 |  | 102.8d |  | John Ryan | 1.6h | 21,000 |
| 14 | 2.5 | GPS | 0.2d | 2011-01-03 | 2011-01-03 |  | 102.8d |  | Gene Massion | 1.6h |  |
| 15 | 2.6 | Buoy accelerometer | 0.2d | 2011-01-03 | 2011-01-03 |  | 102.8d |  | Gene Massion | 1.6h |  |
| 16 | 2.7 | Spares | 0.2d | 2011-01-03 | 2011-01-03 |  | 102.8d |  | Gene Massion | 1.6h |  |
| 17 | 3 | **Build** | 174d? | 2011-01-03 | 2011-09-01 |  | -41d | 0d |  | 760h |  |
| 18 | 3.1 | **2 new battery housings** | 4d? | 2011-01-03 | 2011-01-06 |  | 129d |  | Mike Parker [50%] | 48h |  |
| 19 | 3.1.1 | Machine Shop | 4d? | 2011-01-03 | 2011-01-06 |  | 129d |  | Machine Shop | 32h |  |
| 20 | 3.2 | **Labview VI** | 30d? | 2011-02-14 | 2011-03-25 | 9 | 73d |  |  | 280h |  |
| 21 | 3.2.1 | Gene Massion | 30d? | 2011-02-14 | 2011-03-25 |  | 73d |  | Gene Massion [50%] | 120h |  |
| 22 | 3.2.2 | Dale Graves | 26.67d? | 2011-02-14 | 2011-03-22 |  | 76.33d |  | Dale Graves [75%] | 160h |  |
| 23 | 3.3 | New recovery cable termination | 2d | 2011-01-03 | 2011-01-04 |  | 131d |  | Machine Shop | 16h |  |
| 24 | 3.4 | ESP mods | 25d? | 2011-03-28 | 2011-04-29 | 1FS+10d | -41d | 0d | Scott Jensen [20%] | 40h |  |

| ID | WBS | Task | Duration | Start | Finish | Predecessors | Total slack | Free slack | Constraint | Resources | Work |
| --- | --- | --- | --- | --- | --- | --- | --- | --- | --- | --- | --- |
| 25 | 3.5 | **"Small Tasks"** | 55d? | 2011-05-02 | 2011-07-15 | 24 | -41d | 0d |  |  | 240h |
| 26 | 3.5.1 | Paul Coenen | 20d? | 2011-05-02 | 2011-05-27 |  | -41d | 0d |  | Paul Coenen [50%] | 80h |
| 27 | 3.5.2 | Mike Parker | 20d? | 2011-05-30 | 2011-06-24 | 26 | -41d | 0d |  | Mike Parker [50%] | 80h |
| 28 | 3.5.3 | Machine Shop | 5d? | 2011-06-27 | 2011-07-01 | 27 | -41d | 0d |  | Machine Shop | 40h |
| 29 | 3.5.4 | Elect. Techs | 10d? | 2011-07-04 | 2011-07-15 | 28 | -41d | 0d |  | Electrical Techs [50%] | 40h |
| 30 | 3.6 | New E/M cable (as req'd) | 5d | 2011-07-18 | 2011-07-22 | 29 | -41d | 0d |  | Jim Scholfield | 40h |
| 31 | 3.7 | Nav System | 15d | 2011-07-25 | 2011-08-12 | 30 | -41d | 0d |  | Gene Massion [33.3%] | 40h |
| 32 | 3.8 | New drag skirt (as req'd) | 10d | 2011-08-15 | 2011-08-26 | 31 | -41d | 0d |  | Mike Parker [50%] | 40h |
| 33 | 3.9 | External sensor brackets | 4d | 2011-08-29 | 2011-09-01 | 32 | -41d | 0d |  | Paul Coenen [50%] | 16h |
| 34 | 4 | **Integrate** | 10d | 2011-09-02 | 2011-09-15 |  | -41d | 0d |  |  | 40h |
| 35 | 4.1 | everything | 10d | 2011-09-02 | 2011-09-15 | 17 | -41d | 0d |  | Gene Massion [50%] | 40h |
| 36 | 5 | **Test** | 204d? | 2011-01-03 | 2011-10-12 |  | 12d |  |  |  | 244h |
| 37 | 5.1 | E/M Cable break strength | 5d | 2011-01-03 | 2011-01-07 |  | 211d |  |  | Jim Scholfield | 40h |
| 38 | 5.2 | **Telemetry System** | 10d? | 2011-02-10 | 2011-02-24 | 10FS+28d | 177.8d |  |  |  | 56h |
| 39 | 5.2.1 | Brent | 10d? | 2011-02-10 | 2011-02-24 |  | 177.8d |  |  | Brent Roman [50%] | 40h |
| 40 | 5.2.2 | Gene | 10d? | 2011-02-10 | 2011-02-24 |  | 177.8d |  |  | Gene Massion [20%] | 16h |
| 41 | 5.3 | system | 20d | 2011-09-16 | 2011-10-12 | 34 | -41d | 0d |  | Gene Massion [50%] | 80h |
| 42 | 5.4 | **rough weather deployment (small buoy)** | 5d? | 2011-01-03 | 2011-01-07 |  | 211d |  |  | Gene Massion [10%] | 44h |
| 43 | 5.4.1 | Paul Coenen | 5d? | 2011-01-03 | 2011-01-07 |  | 211d |  |  | Paul Coenen | 40h |
| 44 | 5.5 | New Buoy | 30d | 2011-03-04 | 2011-04-14 | 12FS+14d | 142d |  |  | Gene Massion [10%] | 24h |
| 45 | 6 | **HI Deployment** | 41d | 2011-09-05 | 2011-10-28 |  | -12d | 0d |  |  | 328h |
| 46 | 6.1 | Prep for shipping | 1d | 2011-10-13 | 2011-10-13 | 41 | -41d | 0d |  | Paul Coenen | 8h |
| 47 | 6.2 | Ship | 10d | 2011-10-14 | 2011-10-27 | 46 | -41d | 0d |  |  | 80h |
| 48 | 6.3 | Mob | 1d | 2011-10-28 | 2011-10-28 | 47 | -41d | 0d |  | Gene Massion | 8h |
| 49 | 6.4 | Deployment 1 | 14d | 2011-09-05 | 2011-09-21 | 48 | -41d | 0d | must start on 2011-09-05 | Gene Massion | 112h |
| 50 | 6.5 | Demob | 3d | 2011-09-22 | 2011-09-26 | 49 | 10d | 0d |  | Gene Massion | 24h |
| 51 | 6.6 | Ship | 10d | 2011-09-27 | 2011-10-10 | 50 | 10d | 0d |  |  | 80h |
| 52 | 6.7 | Cleanup | 4d | 2011-10-11 | 2011-10-14 | 51 | 10d |  |  | Paul Coenen [50%] | 16h |
